# مونولیت

Schedule from MS Project, 2020-12-21 to 2021-12-22.

## Calendars

- مونولیت: Mon-Wed 07:00-15:00; Thu-Fri off; Sat-Sun 07:00-15:00.

## Schedule

| ID | WBS | Task | Type | Duration | Start | Finish | Predecessors | Total slack | Text1 | پایان |
| --- | --- | --- | --- | --- | --- | --- | --- | --- | --- | --- |
| 1 | 1 | شروع | milestone | 0d | 2020-12-21 | 2020-12-21 |  | 0d | 1399/10/1 | 1399/10/1 |
| 2 | 2 | **فاز 1:** |  | 87d | 2020-12-21 | 2021-04-20 |  | 0d | 1399/10/1 | 1400/1/31 |
| 3 | 2.1 | تعیین و معرفی خواص مونولیت‌های کوردیریتی |  | 22d | 2020-12-21 | 2021-01-19 | 1 | 0d | 1399/10/1 | 1399/10/30 |
| 4 | 2.2 | تهیه استانداردهای مربوط به مونولیت‌های کوردیریتی |  | 11d | 2021-01-20 | 2021-02-03 | 3 | 0d | 1399/11/1 | 1399/11/15 |
| 5 | 2.3 | معرفی تولیدکننده‌های مونولیت خودرو در جهان |  | 10d | 2021-02-06 | 2021-02-17 | 4 | 0d | 1399/11/18 | 1399/11/29 |
| 6 | 2.4 | تعیین ویژگی‌های مواد اولیه مورد نیاز |  | 17d | 2021-02-20 | 2021-03-14 | 5 | 0d | 1399/12/2 | 1399/12/24 |
| 7 | 2.5 | تعیین فناوری ساخت مونولیت‌های کوردیریتی |  | 27d | 2021-03-15 | 2021-04-20 | 6 | 0d | 1399/12/25 | 1400/1/31 |
| 8 | 3 | **فاز 2:** |  | 44d | 2021-04-21 | 2021-06-21 |  | 0d | 1400/2/1 | 1400/3/31 |
| 9 | 3.1 | بررسی جامع معادن و منابع تامین‌کننده خاک‌های مورد نیاز و تهیه بانک اطلاعاتی از آن‌ها |  | 17d | 2021-04-21 | 2021-05-15 | 7 | 0d | 1400/2/1 | 1400/2/25 |
| 10 | 3.2 | انتخاب مواد اولیه مناسب |  | 19d | 2021-05-16 | 2021-06-09 | 9 | 0d | 1400/2/26 | 1400/3/19 |
| 11 | 3.3 | تعیین مشخصات فنی تجهیزات و برنامه‌ريزي در زمینه خرید تجهیزات لازم |  | 24d | 2021-05-19 | 2021-06-21 | 10SS+3d | 0d | 1400/2/29 | 1400/3/31 |
| 12 | 4 | **فاز 3:** |  | 87d | 2021-06-22 | 2021-10-20 |  | 0d | 1400/4/1 | 1400/7/28 |
| 13 | 4.1 | تهیه فرمولاسیون مناسب با خواص مشابه با نمونه شاهد (پودر کوردیریت) با حداکثر استفاده از مواد ایرانی |  | 22d | 2021-06-22 | 2021-07-21 | 11 | 0d | 1400/4/1 | 1400/4/30 |
| 14 | 4.2 | تهیه گل و بررسی رفتار رئولوژی آن |  | 22d | 2021-07-24 | 2021-08-22 | 13 | 0d | 1400/5/2 | 1400/5/31 |
| 15 | 4.3 | شکل‌دهی گل و بررسی رفتار شکل‌پذیری آن |  | 23d | 2021-08-23 | 2021-09-22 | 14 | 0d | 1400/6/1 | 1400/6/31 |
| 16 | 4.4 | تهیه نمودار پخت |  | 20d | 2021-09-25 | 2021-10-20 | 15 | 0d | 1400/7/3 | 1400/7/28 |
| 17 | 5 | **فاز 4:** |  | 263d? | 2020-12-21 | 2021-12-22 |  | 0d | 1399/10/1 | 1400/10/1 |
| 18 | 5.1 | مقایسه خواص پودر کوردیریت با نمونه شاهد و بهینه‌سازی خواص |  | 23d | 2021-10-23 | 2021-11-22 | 16 | 0d | 1400/8/1 | 1400/9/1 |
| 19 | 5.2 | پخت خمیر اکسترود شده و مقایسه خواص آن با نمونه شاهد |  | 10d | 2021-11-23 | 2021-12-06 | 18 | 0d | 1400/9/2 | 1400/9/15 |
| 20 | 5.3 | ارائه فرمولاسیون نهایی، تولید پودر کوردیریت با خواص مشابه نمونه شاهد |  | 12d | 2021-12-07 | 2021-12-22 | 19 | 0d | 1400/9/16 | 1400/10/1 |
| 23 | 5.4 | اخذ جواز تأسیس واحد صنعتی | inactive | 1d? | 2020-12-21 | 2020-12-21 |  | 262d | 1399/10/1 | 1399/10/1 |
| 24 | 5.5 | خرید زمین و تآمین زیر ساخت | inactive | 1d? | 2020-12-21 | 2020-12-21 |  | 262d | 1399/10/1 | 1399/10/1 |
| 25 | 5.6 | خرید و نصب تجهیزات | inactive | 1d? | 2020-12-21 | 2020-12-21 |  | 262d | 1399/10/1 | 1399/10/1 |
| 26 | 5.7 | ساخت نمونه اصلی مونولیت | inactive, manual | 1d? | 2020-12-21 | 2020-12-21 |  |  | 1399/10/1 | 1399/10/1 |
| 27 | 5.8 | اخذ استانداردهای لازم مونولیت | inactive | 1d? | 2020-12-21 | 2020-12-21 |  | 262d | 1399/10/1 | 1399/10/1 |
| 28 | 5.9 | راه اندازی پایلوت تولید قطعه مونولیت | inactive | 1d? | 2020-12-21 | 2020-12-21 |  | 262d | 1399/10/1 | 1399/10/1 |
